# GERAN2 work plan

Schedule from MS Project, 2001-05-11 to 2004-11-12, A marks actual dates.
3GPP work plan
Vodafone Group
Tel: +44 1635 676093 / E-mail: jose-luis.carrizo@vodafone.co.uk

## Calendars

- Standard: Mon-Fri 08:00-12:00, 13:00-17:00; Sat-Sun off.

## Resources

| Resource |
| --- |
| TSG GERAN |
| WG GERAN1 |
| WG GERAN2 |
| WG GERAN4 |
| GERAN1 |
| G2 |
| GERAN4/5 |
| GERAN 4/5 |
| GERAN3 |
| CN1 |
| SA1 |
| SA2 |
| TSG RAN |
| TSG CN |
| SA3 |
| GP |
| G4 |
| G5 |
| S1 |
| S2 |
| R2 |
| N1 |
| S3 |
| G1 |
| G2 |
| G3 |

## Schedule

| ID | WBS | Task | Duration | Start | Finish | Predecessors | Complete | Remaining | Baseline start | Baseline finish | Baseline duration | Total slack | Free slack | Constraint | Resources | Work | Actual work | Text6 | Text1 | Text2 | Text3 | Text8 | Text9 | Text7 |
| --- | --- | --- | --- | --- | --- | --- | --- | --- | --- | --- | --- | --- | --- | --- | --- | --- | --- | --- | --- | --- | --- | --- | --- | --- |
| 1 | 1 | VERSION 10.0 (10 October 2003) | 1d | 2002-01-01 | 2002-01-01 |  |  |  | 2000-01-03 | 2000-01-03 | 1d | 748d |  |  |  |  |  | Rel |  |  |  |  |  |  |
| 3 | 4 | **Flexible Layer One for GERAN** | 461d | 2002-04-19 A | 2004-01-23 |  | 53% | 215.21d | 2000-01-03 | 2002-06-28 | 650d | 210d |  |  | GP | 11624h | 4039.2h | Rel6 | FLOGER | Benoist Sébire, Nokia | benoist.sebire@nokia.com |  |  |  |
| 4 | 4.1 | Realisation of a Flexible Layer One | 416d | 2002-04-19 A | 2003-11-21 |  | 65% | 145.6d | 2000-01-03 | 2002-06-28 | 650d | 210d | 0d | finish no earlier than 2003-11-21 | GP | 3328h | 2163.2h |  | FLOGER-Real | Benoist Sébire, Nokia | benoist.sebire@nokia.com |  |  |  |
| 5 | 4.2 | Signalling and protocol support for a Flexible Layer One | 295d | 2002-10-07 A | 2003-11-21 |  | 30% | 206.5d | 2002-04-19 | 2002-06-28 | 51d | 210d | 0d | finish no earlier than 2003-11-21 | G2 | 2360h | 708h |  | FLOGER-SigPro | Benoist Sébire, Nokia | benoist.sebire@nokia.com |  |  |  |
| 6 | 4.3 | Security for a Flexible Layer One | 146d | 2003-02-07 A | 2003-08-29 A |  | 100% |  | 2002-04-19 | 2002-06-28 | 51d |  |  | finish no earlier than 2003-08-29 | G2 | 1168h | 1168h |  | FLOGER-SecFLO | Benoist Sébire, Nokia | benoist.sebire@nokia.com |  |  |  |
| 7 | 4.4 | GERAN MS Conformance test for the Flexible Layer One | 45d | 2003-11-24 | 2004-01-23 | 4, 5, 6 |  |  | 2002-04-19 | 2002-06-28 | 51d | 210d |  | finish no earlier than 2004-01-23 | G4; G5 | 720h |  |  | FLOGER-Msconf | Benoist Sébire, Nokia | benoist.sebire@nokia.com |  |  |  |
| 8 | 4.5 | GERAN BTS Conformance test for the Flexible Layer One | 45d | 2003-11-24 | 2004-01-23 | 4, 5, 6 |  |  | 2002-04-19 | 2002-06-28 | 51d | 210d |  | finish no earlier than 2004-01-23 | G3 | 360h |  |  | FLOGER-BTSconf | Benoist Sébire, Nokia | benoist.sebire@nokia.com |  |  |  |
| 9 | 6 | **Multimedia Broadcast and Multicast Service** | 741d | 2001-05-11 A | 2004-03-12 |  | 53% | 347.09d | 2001-05-11 | 2003-09-30 | 623d | 175d |  |  |  | 22568h | 11370.6h | Rel6 | MBMS |  |  | Michael C. |  |  |
| 10 | 6.1 | Stage 1 | 232d | 2001-05-11 A | 2002-04-01 A |  | 100% |  | 2001-05-11 | 2002-04-01 | 232d |  |  | finish no earlier than 2002-04-01 | S1 | 1856h | 1856h |  |  |  |  | Micheal C | 11003 |  |
| 11 | 6.2 | **Stage 2** | 593d | 2001-09-24 A | 2003-12-31 |  | 91% | 53.25d | 2001-08-31 | 2002-09-20 | 276d | 227d |  |  | S2 | 9528h | 6249.85h |  |  |  |  |  |  | TSG |
| 12 | 6.2.1 | TR on Architectural Study | 240d | 2001-09-24 A | 2002-08-23 A |  | 100% |  |  |  |  |  |  | finish no earlier than 2002-08-23 | S2 | 1920h | 1920h |  |  |  |  |  |  |  |
| 13 | 6.2.2 | Stage 2 Specification Work | 358d | 2002-08-19 A | 2003-12-31 |  | 85% | 53.7d |  |  |  | 227d |  | finish no earlier than 2003-12-31 | S2 | 2864h | 2434.4h |  |  |  |  |  |  |  |
| 14 | 6.3 | Introduction of MBMS in RAN | 449d | 2002-01-01 A | 2003-09-19 |  | 40% | 269.4d | 2002-01-01 | 2003-09-30 | 456d | 300d |  | finish no earlier than 2003-09-19 | R2 | 3592h | 1436.8h |  |  | Dimitris Koulakiotis, Nokia |  |  | 2481 | TSG |
| 15 | 6.4 | Support of the MBMS in CN protocols | 454d | 2002-06-18 A | 2004-03-12 |  | 25% | 340.5d |  |  |  | 175d |  | finish no earlier than 2004-03-12 | N1 | 3632h | 908h |  |  |  |  |  |  | TSG |
| 16 | 6.5 | Security Aspects of Multimedia Broadcast/Multicast Service (MBMS) | 175d | 2002-07-01 A | 2003-02-28 |  | 20% | 140d |  |  |  | 445d |  | finish no earlier than 2003-02-28 | S3 | 1400h | 280h |  | MBMS | Escott, Adrian, Hutchison 3G UK | adrian.escott@hutchison3g.com |  |  | TSG |
| 17 | 6.6 | Support of MBMS in GERAN | 320d | 2002-11-18 A | 2004-02-06 |  | 25% | 240d |  |  |  | 200d |  | finish no earlier than 2004-02-06 | GP | 2560h | 640h | Rel6 | MBMS-GERAN | José Luis Carrizo Martínez, Vodafone | jose-luis.carrizo@gb.vodafone.co.uk |  |  | TSG |
| 18 | 7 | **Seamless support of streaming services in A/Gb mode** | 431d | 2002-08-30 A | 2004-04-23 |  | 75% | 108.08d |  |  |  | 145d |  |  | GP | 12064h | 8379.33h | Rel6 | SSStrea | José Luis Carrizo Martínez, Vodafone | jose-luis.carrizo@gb.vodafone.co.uk |  |  |  |
| 19 | 7.1 | Identification of requirements for streaming | 261d | 2002-08-30 A | 2003-08-29 A |  | 100% |  |  |  |  |  |  | finish no earlier than 2003-08-29 | GP | 2088h | 2088h |  |  | José Luis Carrizo Martínez, Vodafone | jose-luis.carrizo@gb.vodafone.co.uk |  |  |  |
| 20 | 7.2 | Performance study of cell change mechanisms | 261d | 2002-08-30 A | 2003-08-29 A |  | 100% |  |  |  |  |  |  | finish no earlier than 2003-08-29 | GP | 2088h | 2088h |  |  | José Luis Carrizo Martínez, Vodafone | jose-luis.carrizo@gb.vodafone.co.uk |  |  |  |
| 21 | 7.3 | Reduction of service interruption times and packet loss during mobility procedures | 225d | 2003-01-13 A | 2003-11-21 | 19, 20 | 90% | 22.5d |  |  |  | 145d | 0d | finish no earlier than 2003-11-21 | GP | 1800h | 1620h |  |  | José Luis Carrizo Martínez, Vodafone | jose-luis.carrizo@gb.vodafone.co.uk |  |  |  |
| 22 | 7.5 | MS conformance testing | 110d | 2003-11-24 | 2004-04-23 | 21 |  |  |  |  |  | 145d |  | finish no earlier than 2004-01-30 | G4; G5 | 1760h |  |  |  |  |  |  |  |  |
| 23 | 7.6 | BTS conformance testing | 110d | 2003-11-24 | 2004-04-23 | 21 |  |  |  |  |  | 145d |  | finish no earlier than 2004-01-30 | G3 | 880h |  |  |  |  |  |  |  |  |
| 24 | 8 | **Uplink TDOA Location Determination for GSM/GPRS** | 516d? | 2002-11-22 A | 2004-11-12 |  | 47% | 275.25d? |  |  |  | 0d |  |  | GP | 10184h | 4751.64h |  | UTDOA | Bob Gross, TruePosition, Inc. | rlgross@trueposition.com |  |  |  |
| 25 | 5.1 | Addition of U-TDOA in the CS domain | 371d? | 2002-11-22 A | 2004-04-23 |  | 90% | 37.1d? |  |  |  | 145d |  | finish no earlier than 2004-04-23 | GP | 2968h | 2671.2h |  | UTDOA-CS |  |  |  |  |  |
| 26 | 5.2 | Addition of U-TDOA in the PS domain | 386d? | 2003-05-23 A | 2004-11-12 |  | 5% | 366.7d? |  |  |  | 0d |  | finish no earlier than 2004-11-12 | GP | 3088h | 154.4h |  | UTDOA-PS |  |  |  |  |  |

Notes:
- 3: Nokia, Ericsson, Siemens, Telia / Text4: Nokia, Ericsson, Siemens, Telia
- 4: Text4: Nokia, Ericsson, Siemens, Telia
- 5: Text4: Nokia, Ericsson, Siemens, Telia
- 6: Text4: Nokia, Ericsson, Siemens, Telia
- 7: Text4: Nokia, Ericsson, Siemens, Telia
- 8: Text4: Nokia, Ericsson, Siemens, Telia
- 9: Title renamed at SA#13
- 10: This may or may not be a separate stage 1. In the meantime, CRs are proposed for 22.101
- 16: WID approved SA#17
- 17: Text4: Ericsson, Nokia, Siemens, Vodafone
- 18: Text4: Ericsson, Nortel Networks, Siemens, T-Mobile, Vodafone
- 19: Text4: Ericsson, Nortel Networks, Siemens, T-Mobile, Vodafone
- 20: Text4: Ericsson, Nortel Networks, Siemens, T-Mobile, Vodafone
- 21: Text4: Ericsson, Nortel Networks, Siemens, T-Mobile, Vodafone
- 24: Text4: Cingular Wireless, AWS, SBC Technology Resources, Motorola, TruePosition

| ID | WBS | Task | Duration | Start | Finish | Predecessors | Complete | Remaining | Total slack | Free slack | Constraint | Resources | Work | Actual work | Text1 | Text2 | Text3 |
| --- | --- | --- | --- | --- | --- | --- | --- | --- | --- | --- | --- | --- | --- | --- | --- | --- | --- |
| 27 | 10 | **Support of Conversational Services in A/Gb Mode via the PS Domain** | 406d? | 2003-02-07 A | 2004-08-27 |  | 18% | 332.96d? | 55d |  |  |  | 7328h | 1318.4h | SCSAGB | David Bladsjö, Ericsson | david.bladsjo@era.ericsson.se |
| 28 | 10.1 | Technical Report | 206d? | 2003-02-07 A | 2003-11-21 |  | 80% | 41.2d? | 145d | 0d | finish no earlier than 2003-11-21 | GP | 1648h | 1318.4h | SCSAGB-TR | David Bladsjö, Ericsson | david.bladsjo@era.ericsson.se |
| 29 | 10.2 | Stage 2 | 110d? | 2003-11-24 | 2004-04-23 | 28 |  |  | 145d |  | finish no earlier than 2004-04-23 | GP | 880h |  | SCSAGB-Stage2 | David Bladsjö, Ericsson | david.bladsjo@era.ericsson.se |
| 30 | 10.7 | Radio Channel Support | 150d? | 2004-02-02 | 2004-08-27 |  |  |  | 55d |  | finish no earlier than 2004-08-27 | GP | 1200h |  | SCSAGB-RCS | David Bladsjö, Ericsson | david.bladsjo@era.ericsson.se |
| 31 | 10.4 | Definition of Radio Resource Management Functionality | 150d? | 2004-02-02 | 2004-08-27 |  |  |  | 55d |  | finish no earlier than 2004-08-27 | GP | 1200h |  | SCSAGB-RRM | David Bladsjö, Ericsson | david.bladsjo@era.ericsson.se |
| 32 | 10.8 | PS Handover | 150d? | 2004-02-02 | 2004-08-27 |  |  |  | 55d |  | finish no earlier than 2004-08-27 | GP | 1200h |  | SCSAGB-PSH | David Bladsjö, Ericsson | david.bladsjo@era.ericsson.se |
| 33 | 10.5 | Modifications to FLO | 150d? | 2004-02-02 | 2004-08-27 |  |  |  | 55d |  | finish no earlier than 2004-08-27 | GP | 1200h |  | SCSAGB-FLO | David Bladsjö, Ericsson | david.bladsjo@era.ericsson.se |

Notes:
- 27: Text4: Alcatel, Cingular Wireless, Ericsson, Nortel Networks, Siemens, T-Mobile, Telecom Italia Mobile, Vodafone Group Plc
- 28: Text4: Alcatel, Cingular Wireless, Ericsson, Nortel Networks, Siemens, T-Mobile, Telecom Italia Mobile, Vodafone Group Plc
- 29: Text4: Alcatel, Cingular Wireless, Ericsson, Nortel Networks, Siemens, T-Mobile, Telecom Italia Mobile, Vodafone Group Plc
- 30: Text4: Alcatel, Cingular Wireless, Ericsson, Nortel Networks, Siemens, T-Mobile, Telecom Italia Mobile, Vodafone Group Plc
- 31: Text4: Alcatel, Cingular Wireless, Ericsson, Nortel Networks, Siemens, T-Mobile, Telecom Italia Mobile, Vodafone Group Plc
- 32: Text4: Alcatel, Cingular Wireless, Ericsson, Nortel Networks, Siemens, T-Mobile, Telecom Italia Mobile, Vodafone Group Plc
- 33: Text4: Alcatel, Cingular Wireless, Ericsson, Nortel Networks, Siemens, T-Mobile, Telecom Italia Mobile, Vodafone Group Plc
